# 20190612 Planning rwzi Nieuwveen DO-Oplevering

Schedule from MS Project, 2021-10-27 to 2024-08-07.
Royal Haskoning

## Calendars

- Standard: Mon-Fri 08:00-12:00, 13:00-17:00; Sat-Sun off. Exceptions (off unless hours are given): 2021-12-27 to 2022-01-07 (kerstvakantie 2021), 2022-08-01 to 2022-08-19 (zomervakantie 2022), 2022-12-24 to 2023-01-08 (kerstvakantie 2022), 2023-07-31 to 2023-08-18 (Zomervakantie 2023), 2023-12-25 to 2024-01-05 (Kerstvakantie 2023).
- werkdagen: Mon-Fri 08:00-12:00, 13:00-17:00; Sat-Sun 09:00-12:00, 13:00-17:00.

## Schedule

| ID | WBS | Task | Type | Duration | Start | Finish | Predecessors | Total slack | Free slack | Calendar |
| --- | --- | --- | --- | --- | --- | --- | --- | --- | --- | --- |
| 1 | 1 | **Activiteiten HHR** |  | 124d | 2021-10-27 | 2022-05-02 |  | 30d |  |  |
| 2 | 1.1 | **Aanbesteding en gunningsfase AKZ** |  | 124d | 2021-10-27 | 2022-05-02 |  | 30d |  |  |
| 3 | 1.1.1 | Voorbereiding aanbesteding |  | 30d | 2021-10-27 | 2021-12-08 | 4SF | 636d |  |  |
| 4 | 1.1.2 | Contractstukken opsturen naar aannemers | manual | 1d | 2021-12-08 | 2021-12-08 |  |  |  |  |
| 5 | 1.1.3 | Rekentijd aannemers + NVI (kalenderdagen) |  | 102ed | 2021-12-08 | 2022-03-20 | 4 | 1.88d |  | werkdagen |
| 6 | 1.1.4 | Indienen aanbestedingsdocumenten aannemers |  | 1d | 2022-03-21 | 2022-03-21 | 5 | 0d |  |  |
| 7 | 1.1.5 | Beoordeling en voorlopige gunning |  | 15d | 2022-03-22 | 2022-04-11 | 6 | 0d |  |  |
| 8 | 1.1.6 | Alcatel periode (kalenderdagen) |  | 21ed | 2022-04-11 | 2022-05-02 | 7 | 1.88d | 0d | werkdagen |
| 9 | 1.1.7 | Definitieve gunning | milestone | 0d | 2022-05-02 | 2022-05-02 | 8 | 0d |  |  |
| 10 | 2 | **UITVOERINGSFASE ZK ALPHEN KERK EN ZANEN** |  | 537d | 2022-05-09 | 2024-08-07 |  | 0d |  |  |
| 11 | 2.1 | Datum aanvang | milestone | 0d | 2022-05-09 | 2022-05-09 | 9FS+5d | 127d | 0d |  |
| 12 | 2.2 | Engineering aannemer |  | 95d | 2022-05-10 | 2022-10-10 | 9, 11 | 127d | 0d |  |
| 13 | 2.3 | Engineerin aannemer gereed [UM] | milestone | 0d | 2022-10-10 | 2022-10-10 | 12 | 442d |  |  |
| 14 | 2.4 | Bestellen/reserveren long lead items (Ontwateringsmachine, silo, roosters, blowers, verdelers) |  | 8mo | 2022-10-11 | 2023-06-05 | 12 | 127d | 0d |  |
| 15 | 2.5 | Bestellen en inkoop mengers en equipement selector en contactruimte |  | 40d | 2022-10-11 | 2022-12-05 | 12 | 208d | 30d |  |
| 16 | 2.6 | Bestellen en produceren skids plaatbeluchting |  | 60d | 2022-10-11 | 2023-01-16 | 12 | 223d | 45d |  |
| 17 | 2.7 | Bestellen en inkoop overige items |  | 80d | 2022-10-11 | 2023-02-13 | 12 | 130d | 0d |  |
| 18 | 2.8 | **Werkzaamheden awzi Alphen Kerk en Zanen** |  | 160d | 2023-01-17 | 2023-09-18 |  | 16d |  |  |
| 19 | 2.8.1 | Mobilisatie |  | 2w | 2023-01-17 | 2023-01-30 | 12, 17FS-20d | 130d | 0d |  |
| 20 | 2.8.2 | **Fase 1 - Contactruimte en anaerobe ruimte** |  | 20d | 2023-01-31 | 2023-02-27 |  | 16d |  |  |
| 21 | 2.8.2.1 | Reinigen contactruimte en anaerobe ruimte |  | 5d | 2023-01-31 | 2023-02-06 | 19, 15 | 178d | 0d |  |
| 22 | 2.8.2.2 | Repareren beton en lining |  | 2w | 2023-02-07 | 2023-02-20 | 21 | 178d | 0d |  |
| 23 | 2.8.2.3 | Monteren en aansluiten mengers (op bestaande voeding) |  | 2w | 2023-02-07 | 2023-02-20 | 21, 15 | 178d | 0d |  |
| 24 | 2.8.2.4 | SAT en IBS |  | 5d | 2023-02-21 | 2023-02-27 | 22, 23 | 178d | 0d |  |

| ID | WBS | Task | Type | Duration | Start | Finish | Predecessors | Total slack | Free slack | Constraint |
| --- | --- | --- | --- | --- | --- | --- | --- | --- | --- | --- |
| 25 | 2.8.3 | **Fase 2 - Aanpassen Beluchtingstank 1** |  | 25d | 2023-02-28 | 2023-04-03 |  | 16d |  |  |
| 26 | 2.8.3.1 | Inblokken, leegpompen en reinigen |  | 1w | 2023-02-28 | 2023-03-06 | 24 | 178d | 0d |  |
| 27 | 2.8.3.2 | Aanpassen luchtleidingen (alleen t.b.v. aansluiten skids platen) |  | 2w | 2023-03-07 | 2023-03-20 | 26 | 178d | 0d |  |
| 28 | 2.8.3.3 | Verwijderen schotels en betonreparaties |  | 2w | 2023-03-07 | 2023-03-20 | 26 | 178d | 0d |  |
| 29 | 2.8.3.4 | Inhijsen skids plaatbeluchting en aansluiten |  | 1w | 2023-03-21 | 2023-03-27 | 28, 27, 16 | 178d | 0d |  |
| 30 | 2.8.3.5 | Vullen en in bedrijf stellen |  | 1w | 2023-03-28 | 2023-04-03 | 29 | 178d | 0d |  |
| 31 | 2.8.4 | **Fase 3 - Aanpassen Beluchtingstank 2** |  | 25d | 2023-04-04 | 2023-05-08 |  | 16d |  |  |
| 32 | 2.8.4.1 | Inblokken, leegpompen en reinigen |  | 1w | 2023-04-04 | 2023-04-10 | 24, 30 | 178d | 0d |  |
| 33 | 2.8.4.2 | Aanpassen luchtleidingen (alleen t.b.v. aansluiten skids platen) |  | 2w | 2023-04-11 | 2023-04-24 | 32 | 178d | 0d |  |
| 34 | 2.8.4.3 | Verwijderen schotels en betonreparaties |  | 2w | 2023-04-11 | 2023-04-24 | 32 | 178d | 0d |  |
| 35 | 2.8.4.4 | Inhijsen skids plaatbeluchting en aansluiten |  | 1w | 2023-04-25 | 2023-05-01 | 33, 34, 16 | 178d | 0d |  |
| 36 | 2.8.4.5 | Vullen en in bedrijf stellen |  | 1w | 2023-05-02 | 2023-05-08 | 35 | 178d | 0d |  |
| 37 | 2.8.5 | **Fase 4** |  | 15d | 2023-05-09 | 2023-05-29 |  | 16d |  |  |
| 38 | 2.8.5.1 | Plaatsen TPI slibretour (1200 m3/uur) |  | 5d | 2023-05-09 | 2023-05-15 | 36 | 178d | 0d |  |
| 39 | 2.8.5.2 | Aanpassen Nabezinktank 2 |  | 2w | 2023-05-16 | 2023-05-29 | 36FS+5d, 38 | 178d | 0d |  |
| 40 | 2.8.6 | **Fase 5** |  | 16d | 2023-05-30 | 2023-06-20 |  | 16d |  |  |
| 41 | 2.8.6.1 | Plaatsen TPI gedeeltelijke bypass 700 mm leiding |  | 4d | 2023-05-30 | 2023-06-02 | 39 | 178d | 0d |  |
| 42 | 2.8.6.2 | Aanpassen Nabezinktank 1 |  | 2w | 2023-06-05 | 2023-06-16 | 39, 41 | 178d | 0d |  |
| 43 | 2.8.6.3 | Ombouw tanks gereed [UM] | milestone | 0d | 2023-06-16 | 2023-06-16 | 42 | 273d |  |  |
| 44 | 2.8.6.4 | Verwijderen TPI's slibretour en bypass verwijderen |  | 2d | 2023-06-19 | 2023-06-20 | 42 | 271d |  |  |
| 45 | 2.8.7 | **Overige aanpassingen:** |  | 160d | 2023-01-17 | 2023-09-18 |  | 130d |  |  |
| 46 | 2.8.7.1 | Rooien begroeiing (Romneyloods, zonneweide en biodiversiteit) na bouwvak ivm broedseizoen |  | 2w | 2023-01-17 | 2023-01-30 | 19FS-10d | 130d | 0d | start no earlier than 2022-08-29 |
| 47 | 2.8.7.2 | Verplaatsen Romneyloods |  | 2w | 2023-01-24 | 2023-02-06 | 46FS-5d | 130d | 0d |  |
| 48 | 2.8.7.3 | Opstellen en aansluiten tijdelijke slibverlading en tijdelijk geurfilter waterlijn |  | 2w | 2023-01-17 | 2023-01-30 | 46SS | 135d | 5d |  |
| 49 | 2.8.7.4 | Slopen slibverlading en geurfilters en overig voorbereiden grondwerk voor Terreinrioolput, E&I gebouw en 2e influentgoot |  | 2w | 2023-02-07 | 2023-02-20 | 48, 47 | 130d | 0d |  |
| 50 | 2.8.7.5 | Schroefpalen voor diverse objecten aanbrengen |  | 2w | 2023-02-21 | 2023-03-06 | 49 | 130d | 0d |  |

| ID | WBS | Task | Duration | Start | Finish | Predecessors | Total slack | Free slack |
| --- | --- | --- | --- | --- | --- | --- | --- | --- |
| 51 | 2.8.7.6 | **Funderingen** | 34d | 2023-02-28 | 2023-04-16 |  | 130d |  |
| 52 | 2.8.7.6.1 | Fundering E&I gebouw | 5d | 2023-02-28 | 2023-03-06 | 50FS-5d | 130d | 0d |
| 53 | 2.8.7.6.2 | Uitharden fundering E&I gebouw | 20ed | 2023-03-06 | 2023-03-26 | 52 | 724.88d | 1.88d |
| 54 | 2.8.7.6.3 | Overige funderingen | 15d | 2023-03-07 | 2023-03-27 | 52 | 130d | 0d |
| 55 | 2.8.7.6.4 | Uitharden funderingen | 20ed | 2023-03-27 | 2023-04-16 | 54 | 610.88d | 1.88d |
| 56 | 2.8.7.7 | **Geurfilters waterlijn** | 25d | 2023-04-17 | 2023-05-19 |  | 198d |  |
| 57 | 2.8.7.7.1 | Plaatsen en aansluiten nieuwe geurfilters waterlijn | 25d | 2023-04-17 | 2023-05-19 | 55, 17 | 198d | 71d |
| 58 | 2.8.7.8 | **E&I gebouw** | 95d | 2023-02-07 | 2023-06-19 |  | 192d |  |
| 59 | 2.8.7.8.1 | Trekputten en mantelbuizen aanbrengen | 4w | 2023-02-07 | 2023-03-06 | 47 | 347d |  |
| 60 | 2.8.7.8.2 | E&I gebouw bouwen | 20d | 2023-03-27 | 2023-04-21 | 53 | 158d | 31d |
| 61 | 2.8.7.8.3 | Verdelers en kasten plaatsen en aansluiten op trafo | 2w | 2023-06-06 | 2023-06-19 | 60, 17, 14 | 127d | 0d |
| 62 | 2.8.7.9 | **Slibontwatering** | 55d | 2023-06-13 | 2023-09-18 |  | 132d |  |
| 63 | 2.8.7.9.1 | Plaatsen tijdelijke slibonwateringsvoorziening | 5d | 2023-06-13 | 2023-06-20 | 64SF | 272d |  |
| 64 | 2.8.7.9.2 | Verwijderen slibontwateringsmachine | 5d | 2023-06-20 | 2023-06-26 | 52FF, 61 | 127d | 0d |
| 65 | 2.8.7.9.3 | Plaatsen Nieuwe slibontwateringsmachine | 5d | 2023-06-20 | 2023-06-26 | 64FS-5d, 14 | 127d | 0d |
| 66 | 2.8.7.9.4 | Plaatsen slibsilo | 5d | 2023-06-20 | 2023-06-26 | 65SS, 14, 55 | 267d |  |
| 67 | 2.8.7.9.5 | Afmonteren ontwateringsinstallaties en slibsilo W+E | 6w | 2023-06-27 | 2023-08-28 | 65 | 127d | 0d |
| 68 | 2.8.7.9.6 | SAT Slibontwatering en storingsvrije periode | 2w | 2023-08-29 | 2023-09-11 | 67 | 127d | 0d |
| 69 | 2.8.7.9.7 | Verwijderen tijdelijke slibontwatering en verlading | 1w | 2023-09-12 | 2023-09-18 | 68 | 127d | 0d |
| 70 | 2.8.7.10 | **Blowers** | 46d | 2023-06-13 | 2023-09-05 |  | 136d |  |
| 71 | 2.8.7.10.1 | Plaatsen aansluiten en testen nieuwe blower 4 | 3w | 2023-06-13 | 2023-07-03 | 61FS-5d, 14 | 136d | 0d |
| 72 | 2.8.7.10.2 | Vervangen blower 1 | 2w | 2023-07-05 | 2023-07-18 | 14, 71FS+1d | 136d | 0d |
| 73 | 2.8.7.10.3 | Vervangen blower 2 | 2w | 2023-07-19 | 2023-08-22 | 72 | 136d | 0d |
| 74 | 2.8.7.10.4 | Vervangen blower 3 | 2w | 2023-08-23 | 2023-09-05 | 73 | 136d | 9d |

| ID | WBS | Task | Duration | Start | Finish | Predecessors | Total slack | Free slack |
| --- | --- | --- | --- | --- | --- | --- | --- | --- |
| 75 | 2.8.7.11 | **Roostergoed** | 94d | 2023-04-17 | 2023-09-14 |  | 129d |  |
| 76 | 2.8.7.11.1 | Bouwen 2e influentgoot en roostergoedgoot | 9w | 2023-04-17 | 2023-06-16 | 50, 55 | 130d | 1d |
| 77 | 2.8.7.11.2 | Opstellen en aansluiten tijdelijke roostergoedinstallatie | 2w | 2023-06-20 | 2023-07-03 | 61, 76 | 129d | 0d |
| 78 | 2.8.7.11.3 | Schuiven, Roostergoedinstallaties aanbrengen, zandvang reinigen en repareren | 30d | 2023-07-04 | 2023-09-04 | 77, 61, 14 | 129d | 0d |
| 79 | 2.8.7.11.4 | Testen en IBS | 5d | 2023-09-05 | 2023-09-11 | 78 | 129d | 0d |
| 80 | 2.8.7.11.5 | Verwijderen tijdelijk roostergoedinstallatie | 3d | 2023-09-12 | 2023-09-14 | 79 | 129d | 2d |
| 81 | 2.8.7.12 | **Terreinriolering en bedrijfswater** | 15d | 2023-06-20 | 2023-07-10 |  | 162d |  |
| 82 | 2.8.7.12.1 | Plaatsen prefab terreinrioolput | 5d | 2023-06-20 | 2023-06-26 | 50FS+10d, 17, 61 | 162d | 0d |
| 83 | 2.8.7.12.2 | Inrichten en aansluiten terreinriolering en afvoer | 10d | 2023-06-27 | 2023-07-10 | 82 | 162d | 35d |
| 84 | 2.8.7.13 | **Retourslibgemaal** | 35d | 2023-06-13 | 2023-08-21 |  | 152d |  |
| 85 | 2.8.7.13.1 | Plaatsen TPI voor retourslib | 5d | 2023-06-13 | 2023-06-19 | 86SS-5d | 272d |  |
| 86 | 2.8.7.13.2 | Slopen installaties | 1w | 2023-06-20 | 2023-06-26 | 61 | 147d | 0d |
| 87 | 2.8.7.13.3 | Betonreparaties | 1w | 2023-06-27 | 2023-07-03 | 86 | 147d | 0d |
| 88 | 2.8.7.13.4 | Monteren nieuwe gemalen | 2w | 2023-07-04 | 2023-07-17 | 87, 17 | 147d | 0d |
| 89 | 2.8.7.13.5 | Indraaien en SAT | 5d | 2023-07-18 | 2023-07-24 | 88 | 147d | 0d |
| 90 | 2.8.7.13.6 | Verwijderen tijdelijke retourslibinstallatie | 5d | 2023-07-25 | 2023-08-21 | 89 | 147d | 20d |
| 91 | 2.8.7.14 | **Afwerken tanks** | 40d | 2023-06-20 | 2023-09-04 |  | 137d |  |
| 92 | 2.8.7.14.1 | Afmonteren en definitief aansluiten apparatuur selector | 2w | 2023-06-20 | 2023-07-03 | 61 | 137d | 0d |
| 93 | 2.8.7.14.2 | Afmonteren en definitief aansluiten apparatuur AT1 | 2w | 2023-07-04 | 2023-07-17 | 92 | 137d | 0d |
| 94 | 2.8.7.14.3 | Afmonteren en definitief aansluiten apparatuur AT2 | 2w | 2023-07-18 | 2023-08-21 | 93 | 137d | 0d |
| 95 | 2.8.7.14.4 | Afmonteren en definitief aansluiten NBT1 | 1w | 2023-08-22 | 2023-08-28 | 94 | 137d | 0d |
| 96 | 2.8.7.14.5 | Afmonteren en definitief aansluiten NBT 2 | 1w | 2023-08-29 | 2023-09-04 | 95 | 137d | 10d |
| 97 | 2.9 | Afronden en ISAT | 6w | 2023-09-19 | 2023-10-30 | 42, 90, 83, 80, 74, 69, 57, 96 | 127d | 0d |
| 98 | 2.10 | **AWTG's** | 216d | 2022-05-10 | 2023-04-11 |  | 256d |  |
| 99 | 2.10.1 | **Werkzaamheden AWTG Alphen West** | 150d | 2022-05-10 | 2023-01-09 |  | 256d |  |
| 100 | 2.10.1.1 | Engineering C/W/E onderdelen lange levertijd | 40d | 2022-05-10 | 2022-07-04 | 11 | 256d | 0d |
| 101 | 2.10.1.2 | Bestellen C/W/E onderdelen lange levertijd | 80d | 2022-06-21 | 2022-10-31 | 100FS-10d | 427d | 0d |
| 102 | 2.10.1.3 | Werkplan TPI | 5d | 2022-05-24 | 2022-05-30 | 100SS+10d | 256d | 0d |
| 103 | 2.10.1.4 | Engineering gereed | 1d | 2022-07-05 | 2022-07-05 | 100 | 496d |  |
| 104 | 2.10.1.5 | Levertijd pompen + FAT | 80d | 2022-06-21 | 2022-10-31 | 101SS | 427d |  |
| 105 | 2.10.1.6 | Levertijd TPI | 70d | 2022-05-31 | 2022-09-26 | 102 | 256d | 0d |
| 106 | 2.10.1.7 | Levertijd schakelkast + FAT | 30d | 2022-06-21 | 2022-08-22 | 101SS | 477d |  |
| 107 | 2.10.1.8 | Plaatsen TPI | 5d | 2022-09-27 | 2022-10-03 | 105 | 256d | 0d |
| 108 | 2.10.1.9 | Proefdraaien TPI | 5d | 2022-10-04 | 2022-10-10 | 107 | 256d | 0d |
| 109 | 2.10.1.10 | Bedrijfsperiode TPI | 55d | 2022-10-11 | 2023-01-09 | 108 | 256d | 0d |
| 110 | 2.10.1.11 | Amoveren bestaande installaties C/W/E | 10d | 2022-10-11 | 2022-10-24 | 109SS | 321d | 0d |
| 111 | 2.10.1.12 | Civiele werkzaamheden | 10d | 2022-10-25 | 2022-11-07 | 110 | 336d | 15d |
| 112 | 2.10.1.13 | Werktuigbouwkundige werkzaamheden | 15d | 2022-10-25 | 2022-11-14 | 110 | 331d | 10d |
| 113 | 2.10.1.14 | Elektrotechnische werkzaamheden | 25d | 2022-10-25 | 2022-11-28 | 110 | 321d | 0d |
| 114 | 2.10.1.15 | Montage eind inspectie (WTB/ E) | 1d | 2022-11-29 | 2022-11-29 | 111, 112, 113 | 321d | 0d |
| 115 | 2.10.1.16 | I/O testen | 5d | 2022-11-30 | 2022-12-06 | 114 | 321d | 0d |
| 116 | 2.10.1.17 | PA Sotware implementeren | 1d | 2022-12-07 | 2022-12-07 | 115 | 321d | 0d |
| 117 | 2.10.1.18 | SAT capaciteitstest 1 | 2d | 2022-12-08 | 2022-12-09 | 116 | 321d | 0d |
| 118 | 2.10.1.19 | Inbedrijfname AWTG | 1d | 2022-12-12 | 2022-12-12 | 117 | 321d | 0d |
| 119 | 2.10.1.20 | 14 dagen test (storingsvrije periode) | 14ed | 2022-12-12 | 2022-12-26 | 118 | 1495.88d | 40.88d |
| 120 | 2.10.1.21 | Restpunten/ Terreinafwerking | 5d | 2022-12-13 | 2022-12-19 | 118 | 326d | 0d |
| 121 | 2.10.1.22 | Opleverdossier | 80d | 2022-08-23 | 2022-12-13 | 100SS, 120SF | 331d | 9d |
| 122 | 2.10.1.23 | Vervroegde ingebruikneming AWTG | 1d | 2023-01-09 | 2023-01-09 | 119, 120, 121 | 322d | 195d |

| ID | WBS | Task | Duration | Start | Finish | Predecessors | Total slack | Free slack |
| --- | --- | --- | --- | --- | --- | --- | --- | --- |
| 123 | 2.10.2 | **Werkzaamheden AWTG Alphen Kerk en Zanen** | 201d | 2022-05-31 | 2023-04-11 |  | 306d |  |
| 124 | 2.10.2.1 | Engineering C/W/E onderdelen lange levertijd | 40d | 2022-05-31 | 2022-07-25 | 100SS+15d | 306d | 0d |
| 125 | 2.10.2.2 | Bestellen C/W/E onderdelen lange levertijd | 80d | 2022-07-12 | 2022-11-21 | 124FS-10d | 316d | 0d |
| 126 | 2.10.2.3 | Werkplan TPI | 5d | 2022-06-14 | 2022-06-20 | 124SS+10d | 306d | 0d |
| 127 | 2.10.2.4 | Engineering gereed | 1d | 2022-07-26 | 2022-07-26 | 124 | 481d |  |
| 128 | 2.10.2.5 | Levertijd pompen + FAT | 80d | 2022-07-12 | 2022-11-21 | 125SS | 412d |  |
| 129 | 2.10.2.6 | Levertijd TPI | 70d | 2022-06-21 | 2022-10-17 | 126 | 306d | 50d |
| 130 | 2.10.2.7 | Levertijd schakelkast + FAT | 30d | 2022-07-12 | 2022-09-12 | 125SS | 462d |  |
| 131 | 2.10.2.8 | Plaatsen TPI | 5d | 2023-01-10 | 2023-01-16 | 129, 109 | 256d | 0d |
| 132 | 2.10.2.9 | Proefdraaien TPI | 5d | 2023-01-17 | 2023-01-23 | 131 | 256d | 0d |
| 133 | 2.10.2.10 | Bedrijfsperiode TPI | 55d | 2023-01-24 | 2023-04-10 | 132 | 256d | 0d |
| 134 | 2.10.2.11 | Amoveren bestaande installaties C/W/E | 10d | 2023-01-24 | 2023-02-06 | 133SS | 256d | 0d |
| 135 | 2.10.2.12 | Civiele werkzaamheden | 25d | 2023-02-07 | 2023-03-13 | 134 | 256d | 0d |
| 136 | 2.10.2.13 | Werktuigbouwkundige werkzaamheden | 10d | 2023-02-07 | 2023-02-20 | 134 | 271d | 15d |
| 137 | 2.10.2.14 | Elektrotechnische werkzaamheden | 25d | 2023-02-07 | 2023-03-13 | 134 | 256d | 0d |
| 138 | 2.10.2.15 | Montage eind inspectie (WTB/ E) | 1d | 2023-03-14 | 2023-03-14 | 135, 136, 137, 148 | 256d | 0d |
| 139 | 2.10.2.16 | I/O testen | 5d | 2023-03-15 | 2023-03-21 | 138 | 256d | 0d |
| 140 | 2.10.2.17 | PA Sotware implementeren | 1d | 2023-03-22 | 2023-03-22 | 139 | 256d | 0d |
| 141 | 2.10.2.18 | SAT capaciteitstest 1 | 2d | 2023-03-23 | 2023-03-24 | 140 | 256d | 0d |
| 142 | 2.10.2.19 | Inbedrijfname AWTG | 1d | 2023-03-27 | 2023-03-27 | 141 | 256d | 0d |
| 143 | 2.10.2.20 | 14 dagen test (storingsvrije periode) | 14ed | 2023-03-27 | 2023-04-10 | 142 | 1180.88d | 1.88d |
| 144 | 2.10.2.21 | Restpunten/ Terreinafwerking | 5d | 2023-03-28 | 2023-04-03 | 142 | 261d | 0d |
| 145 | 2.10.2.22 | Opleverdossier | 80d | 2022-11-22 | 2023-03-28 | 124SS, 144SF | 266d | 10d |
| 146 | 2.10.2.23 | Vervroegde ingebruikneming AWTG | 1d | 2023-04-11 | 2023-04-11 | 143, 144, 145 | 256d | 129d |

| ID | WBS | Task | Type | Duration | Start | Finish | Predecessors | Total slack | Free slack | Constraint |
| --- | --- | --- | --- | --- | --- | --- | --- | --- | --- | --- |
| 147 | 2.10.3 | **Werkzaamheden AWTG Hazerwoude Rijndijk** |  | 16d | 2022-11-14 | 2022-12-06 |  | 321.5d |  |  |
| 148 | 2.10.3.1 | Civiele werkzaamheden |  | 10d | 2022-11-22 | 2022-12-05 | 125 | 316d | 60d |  |
| 149 | 2.10.3.2 | Monteren en aansluiten meting |  | 2d | 2022-11-22 | 2022-11-23 | 125 | 401.5d | 0d |  |
| 150 | 2.10.3.3 | Montage eind inspectie (WTB/ E) |  | 1d | 2022-11-24 | 2022-11-24 | 149 | 401.5d | 0d |  |
| 151 | 2.10.3.4 | I/O testen |  | 0.5d | 2022-11-25 | 2022-11-25 | 150 | 401.5d | 0d |  |
| 152 | 2.10.3.5 | PA Sotware implementeren |  | 0.5d | 2022-11-25 | 2022-11-25 | 151 | 401.5d | 0d |  |
| 153 | 2.10.3.6 | SAT capaciteitstest 1 |  | 0.5d | 2022-11-28 | 2022-11-28 | 152 | 401.5d | 0d |  |
| 154 | 2.10.3.7 | Inbedrijfname AWTG | milestone | 0d | 2022-11-28 | 2022-11-28 | 153 | 401.5d | 0d |  |
| 155 | 2.10.3.8 | Restpunten/ Terreinafwerking |  | 5d | 2022-11-28 | 2022-12-05 | 154 | 401.5d | 0d |  |
| 156 | 2.10.3.9 | Opleverdossier |  | 10d | 2022-11-14 | 2022-11-28 | 155SF | 406.5d | 5d |  |
| 157 | 2.10.3.10 | Vervroegde ingebruikneming AWTG |  | 1d | 2022-12-05 | 2022-12-06 | 155, 156 | 401.5d |  |  |
| 158 | 2.11 | Oplevering (MIJLPAAL) | milestone | 0d | 2023-10-30 | 2023-10-30 | 97, 146, 122 | 127d | 0d |  |
| 159 | 2.12 | Restpunten en nazorg |  | 13w | 2023-10-31 | 2024-02-12 | 158 | 127d |  |  |
| 161 | 2.13 | **UITVOERINGSFASE ZK ALPHEN NOORD** |  | 537d | 2022-05-09 | 2024-08-07 |  | 0d |  |  |
| 162 | 2.13.1 | Datum van aanvang | milestone | 0d | 2022-05-09 | 2022-05-09 | 9FS+5d | 0d |  |  |
| 163 | 2.13.2 | Engineering aannemer |  | 95d | 2022-05-10 | 2022-10-10 | 162 | 0d |  |  |
| 164 | 2.13.3 | Engineering aannemer gereed [UM] | milestone | 0d | 2022-10-10 | 2022-10-10 | 163 | 442d |  |  |
| 165 | 2.13.4 | Bestellen/reserveren long lead items (Ontwateringsmachine, silo, blowers) |  | 8mo | 2022-10-11 | 2023-06-05 | 163 | 0d |  |  |
| 166 | 2.13.5 | Bestellen en inkoop |  | 80d | 2022-10-11 | 2023-02-13 | 163 | 105d |  |  |
| 167 | 2.13.6 | **Werkzaamheden awzi Alphen Noord** |  | 435d | 2022-06-30 | 2024-05-08 |  | 65d |  |  |
| 168 | 2.13.6.1 | **Fase 0** |  | 0d | 2022-06-30 | 2022-06-30 |  | 500d |  |  |
| 169 | 2.13.6.1.1 | Aansluiting aangepast (Liander) | milestone | 0d | 2022-06-30 | 2022-06-30 |  | 500d |  | start no earlier than 2022-06-30 |
| 170 | 2.13.6.2 | **Fase 1** |  | 25d | 2022-10-11 | 2022-11-14 |  | 20d |  |  |
| 171 | 2.13.6.2.1 | Mobilisatie |  | 2w | 2022-10-11 | 2022-10-24 | 163 | 20d | 0d |  |
| 172 | 2.13.6.2.2 | Verplaatsen Lavafilter + slopen + paalfundering aanbrengen (boren) |  | 4w | 2022-10-11 | 2022-11-07 | 171SS | 20d | 0d |  |
| 173 | 2.13.6.2.3 | Installeren bemaling |  | 10d | 2022-11-01 | 2022-11-14 | 172FS-5d | 20d | 0d |  |

| ID | WBS | Task | Type | Duration | Start | Finish | Predecessors | Total slack | Free slack |
| --- | --- | --- | --- | --- | --- | --- | --- | --- | --- |
| 174 | 2.13.6.3 | **Fase 2** |  | 200d | 2022-11-15 | 2023-09-25 |  | 20d |  |
| 175 | 2.13.6.3.1 | Ontgraven bouwkuip (talud 1:2) voor OW+SE+SS+ER |  | 5d | 2022-11-15 | 2022-11-21 | 172, 173 | 20d | 0d |
| 176 | 2.13.6.3.2 | **ONTVANGWERK + SLIBONTWATERING +SILO+ E-RUIMTES + LEIDINGEN** |  | 195d | 2022-11-22 | 2023-09-25 |  | 20d |  |
| 177 | 2.13.6.3.2.1 | vloer + kespen leidingen |  | 5w | 2022-11-22 | 2023-01-09 | 175 | 20d | 0d |
| 178 | 2.13.6.3.2.2 | wanden |  | 6w | 2023-01-10 | 2023-02-20 | 177 | 20d | 0d |
| 179 | 2.13.6.3.2.3 | dek + uitharden |  | 4w | 2023-02-21 | 2023-03-20 | 178 | 20d | 0d |
| 180 | 2.13.6.3.2.4 | Aanbrengen staalconstructies en leuningen |  | 2w | 2023-03-07 | 2023-03-20 | 179FF | 337d |  |
| 181 | 2.13.6.3.2.5 | bouwkundige afwerking gebouw (rekening houden met stempels) |  | 7w | 2023-03-21 | 2023-05-08 | 179 | 20d | 0d |
| 182 | 2.13.6.3.2.6 | watertesten putten + leidingen |  | 10d | 2023-03-21 | 2023-04-03 | 178, 179 | 25d | 0d |
| 183 | 2.13.6.3.2.7 | Spanningsbemaling uit | milestone | 0d | 2023-04-03 | 2023-04-03 | 182 | 327d |  |
| 184 | 2.13.6.3.2.8 | aanvullen |  | 1w | 2023-04-04 | 2023-04-10 | 182 | 25d | 0d |
| 185 | 2.13.6.3.2.9 | container- en lavafilteropstelplaats |  | 3w | 2023-04-11 | 2023-05-01 | 184 | 25d | 5d |
| 186 | 2.13.6.3.2.10 | Silo + trap +bordessen plaatsen |  | 2w | 2023-04-11 | 2023-04-24 | 184 | 30d | 10d |
| 187 | 2.13.6.3.2.11 | geschikt voor W installatie | milestone | 0w | 2023-05-08 | 2023-05-08 | 181, 184, 185, 186 | 20d |  |
| 188 | 2.13.6.3.2.12 | Aanbrengen W en E installatie |  | 13w | 2023-06-06 | 2023-09-25 | 165, 187 | 0d |  |
| 189 | 2.13.6.3.2.13 | Aansluiten gebruikers bestaande installatie + gebruikers nieuwbouw op nieuwe MCC/MRK, zuivering blijft operationeel |  | 13w | 2023-06-06 | 2023-09-25 | 188FF | 0d |  |
| 190 | 2.13.6.3.2.14 | Aanpassen Terreinriolering en bedrijfswater in BG2 |  | 2w | 2023-09-12 | 2023-09-25 | 189FF | 127d | 89d |
| 191 | 2.13.6.4 | **Fase 3** |  | 40d | 2023-07-11 | 2023-09-25 |  | 0d |  |
| 192 | 2.13.6.4.1 | Aanpassen beluchtingstank 1 |  | 8w | 2023-07-11 | 2023-09-25 | 166, 189FF, 43 | 0d |  |
| 193 | 2.13.6.4.2 | Plaatsen tijdelijke beluchtingsinstallatie [TBI] |  | 1w | 2023-08-22 | 2023-08-28 | 188FS-25d, 192SS-5d | 217d | 0d |
| 194 | 2.13.6.4.3 | Vervangen blowerinstallatie en definitief aansluiten BT's |  | 4w | 2023-08-29 | 2023-09-25 | 193 | 217d |  |
| 195 | 2.13.6.5 | **Fase 4** |  | 40d | 2023-09-28 | 2023-11-22 |  | 0d |  |
| 196 | 2.13.6.5.1 | Aanpassen beluchtingstank 2 |  | 8w | 2023-09-28 | 2023-11-22 | 192FS+2d | 0d |  |
| 197 | 2.13.6.6 | **Fase 5** |  | 55d | 2023-11-09 | 2024-02-07 |  | 0d |  |
| 198 | 2.13.6.6.1 | Plaatsen en aansluiten TPI naar BT1 en BT2 vanaf nieuw roostergoedgebouw; [TPI] |  | 2w | 2023-11-09 | 2023-11-22 | 196FS-10d, 199SS | 0d |  |
| 199 | 2.13.6.6.2 | Plaatsen en aansluiten tijdelijk leidingwerk voor leeg pompen VBT |  | 2w | 2023-11-09 | 2023-11-22 | 196FS-10d | 0d |  |
| 200 | 2.13.6.6.3 | Buitengebruik stellen spoelen en leeg pompen voorbezinktank |  | 1w | 2023-11-23 | 2023-11-29 | 198 | 0d |  |
| 201 | 2.13.6.6.4 | Plaatsen en aansluiten TPI voor slibretourgemalen [TPI], afdichten verzamelput voor slibretourgemalen |  | 1w | 2023-11-23 | 2023-11-29 | 200FF | 40d | 0d |
| 202 | 2.13.6.6.5 | Aanpassen selector (incl. reinigen) |  | 4w | 2023-11-30 | 2024-01-10 | 198, 200 | 38d | 0d |
| 203 | 2.13.6.6.6 | Vervangen slibretourgemalen |  | 4w | 2023-11-30 | 2024-01-10 | 201 | 40d | 2d |
| 204 | 2.13.6.6.7 | Wachttijd ivm herstel SVI |  | 4w | 2024-01-11 | 2024-02-07 | 202 | 20d | 0d |

| ID | WBS | Task | Type | Duration | Start | Finish | Predecessors | Total slack | Free slack |
| --- | --- | --- | --- | --- | --- | --- | --- | --- | --- |
| 205 | 2.13.6.7 | **Fase 6** |  | 10d | 2024-02-08 | 2024-02-21 |  | 20d |  |
| 206 | 2.13.6.7.1 | Aanpassen Nabezinktank 2 |  | 2w | 2024-02-08 | 2024-02-21 | 202FS+2d, 203, 204 | 20d | 0d |
| 207 | 2.13.6.8 | **Fase 7** |  | 120d | 2023-10-05 | 2024-04-03 |  | 90d |  |
| 208 | 2.13.6.8.1 | Aanpassen Nabezinktank 1 |  | 2w | 2024-02-22 | 2024-03-06 | 206 | 20d | 0d |
| 209 | 2.13.6.8.2 | Afronden en Capaciteitstest [TPI] |  | 4w | 2024-03-07 | 2024-04-03 | 190, 208 | 20d | 0d |
| 210 | 2.13.6.8.3 | AWZI volledig functioneel | milestone | 0d | 2024-04-03 | 2024-04-03 | 209 | 20d | 0d |
| 211 | 2.13.6.8.4 | Opleverdossier |  | 120d | 2023-10-05 | 2024-04-03 | 210FF | 90d |  |
| 212 | 2.13.6.9 | **Fase 8** |  | 105d | 2023-11-30 | 2024-05-08 |  | 0d |  |
| 213 | 2.13.6.9.1 | Slopen VBT + RGB + BG1 +SC (incl. bemaling) |  | 16w | 2023-11-30 | 2024-04-03 | 200 | 0d |  |
| 214 | 2.13.6.9.2 | Afwerken terrein, inclusief biodiversiteitsmaatregelen; |  | 4w | 2024-04-04 | 2024-05-01 | 213 | 0d |  |
| 215 | 2.13.6.9.3 | Demobilisatie. |  | 1w | 2024-05-02 | 2024-05-08 | 210, 214 | 0d |  |
| 216 | 2.13.7 | **Werkzaamheden AWTG Alphen Kennedylaan [TPI]** |  | 150d | 2022-05-10 | 2023-01-09 |  | 326d |  |
| 217 | 2.13.7.1 | Engineering C/W/E onderdelen lange levertijd |  | 40d | 2022-05-10 | 2022-07-04 | 162 | 326d | 0d |
| 218 | 2.13.7.2 | Bestellen C/W/E onderdelen lange levertijd |  | 80d | 2022-06-21 | 2022-10-31 | 217FS-10d | 427d | 0d |
| 219 | 2.13.7.3 | Werkplan TPI |  | 5d | 2022-05-24 | 2022-05-30 | 217SS+10d | 326d | 0d |
| 220 | 2.13.7.4 | Engineering gereed |  | 1d | 2022-07-05 | 2022-07-05 | 217 | 496d |  |
| 221 | 2.13.7.5 | Levertijd TPI |  | 70d | 2022-05-31 | 2022-09-26 | 219 | 326d | 0d |
| 222 | 2.13.7.6 | Levertijd schakelkast + FAT |  | 30d | 2022-06-21 | 2022-08-22 | 218SS | 477d |  |
| 223 | 2.13.7.7 | Plaatsen TPI |  | 5d | 2022-09-27 | 2022-10-03 | 221 | 326d | 0d |
| 224 | 2.13.7.8 | Proefdraaien TPI |  | 5d | 2022-10-04 | 2022-10-10 | 223 | 326d | 0d |
| 225 | 2.13.7.9 | Bedrijfsperiode TPI |  | 55d | 2022-10-11 | 2023-01-09 | 224 | 326d | 0d |
| 226 | 2.13.7.10 | Amoveren bestaande installaties C/W/E |  | 10d | 2022-10-11 | 2022-10-24 | 225SS | 326d | 0d |
| 227 | 2.13.7.11 | Civiele werkzaamheden |  | 15d | 2022-10-25 | 2022-11-14 | 226 | 336d | 10d |
| 228 | 2.13.7.12 | Werktuigbouwkundige werkzaamheden |  | 15d | 2022-10-25 | 2022-11-14 | 226 | 336d | 10d |
| 229 | 2.13.7.13 | Elektrotechnische werkzaamheden |  | 25d | 2022-10-25 | 2022-11-28 | 226 | 326d | 0d |
| 230 | 2.13.7.14 | Montage eind inspectie (WTB/ E) |  | 1d | 2022-11-29 | 2022-11-29 | 227, 228, 229 | 326d | 0d |
| 231 | 2.13.7.15 | I/O testen |  | 5d | 2022-11-30 | 2022-12-06 | 230 | 326d | 0d |
| 232 | 2.13.7.16 | PA Sotware implementeren |  | 1d | 2022-12-07 | 2022-12-07 | 231 | 326d | 0d |
| 233 | 2.13.7.17 | SAT capaciteitstest 1 |  | 2d | 2022-12-08 | 2022-12-09 | 232 | 326d | 0d |
| 234 | 2.13.7.18 | Inbedrijfname AWTG |  | 1d | 2022-12-12 | 2022-12-12 | 233 | 326d | 0d |
| 235 | 2.13.7.19 | 7 dagen test (storingsvrije periode) |  | 7ed | 2022-12-12 | 2022-12-19 | 234 | 1516.88d | 1.88d |
| 236 | 2.13.7.20 | Restpunten/ Terreinafwerking |  | 5d | 2022-12-13 | 2022-12-19 | 234 | 326d | 0d |
| 237 | 2.13.7.21 | Opleverdossier |  | 80d | 2022-08-23 | 2022-12-13 | 217SS, 236SF | 331d | 5d |
| 238 | 2.13.7.22 | Vervroegde ingebruikneming AWTG |  | 1d | 2022-12-20 | 2022-12-20 | 235, 236, 237 | 326d |  |
| 239 | 2.13.8 | Oplevering (MIJLPAAL) | milestone | 0d | 2024-05-08 | 2024-05-08 | 213, 215, 238 | 0d |  |
| 240 | 2.13.9 | Restpunten en nazorg |  | 13w | 2024-05-09 | 2024-08-07 | 239 | 0d |  |
