# 20190612 Planning rwzi Nieuwveen DO-Oplevering

Schedule from MS Project, 2021-10-27 to 2024-08-07.
Royal Haskoning

## Calendars

- Standard: Mon-Fri 08:00-12:00, 13:00-17:00; Sat-Sun off. Exceptions (off unless hours are given): 2021-12-27 to 2022-01-07 (kerstvakantie 2021), 2022-08-01 to 2022-08-19 (zomervakantie 2022), 2022-12-24 to 2023-01-08 (kerstvakantie 2022), 2023-07-31 to 2023-08-18 (Zomervakantie 2023), 2023-12-25 to 2024-01-05 (Kerstvakantie 2023).
- werkdagen: Mon-Fri 08:00-12:00, 13:00-17:00; Sat-Sun 09:00-12:00, 13:00-17:00.

## Schedule

| ID | WBS | Task | Type | Duration | Start | Finish | Predecessors | Total slack | Free slack | Constraint | Calendar |
| --- | --- | --- | --- | --- | --- | --- | --- | --- | --- | --- | --- |
| 1 | 1 | **Activiteiten HHR** |  | 124d | 2021-10-27 | 2022-05-02 |  | 30d |  |  |  |
| 2 | 1.1 | **Aanbesteding en gunningsfase AN** |  | 124d | 2021-10-27 | 2022-05-02 |  | 30d |  |  |  |
| 3 | 1.1.1 | Voorbereiding aanbesteding |  | 30d | 2021-10-27 | 2021-12-08 | 4SF | 636d |  |  |  |
| 4 | 1.1.2 | Contractstukken opsturen naar aannemers | manual | 1d | 2021-12-08 | 2021-12-08 |  |  |  |  |  |
| 5 | 1.1.3 | Rekentijd aannemers + NVI (kalenderdagen) |  | 101ed | 2021-12-08 | 2022-03-19 | 4 | 4.88d |  |  | werkdagen |
| 6 | 1.1.4 | Indienen aanbestedingsdocumenten aannemers |  | 1d | 2022-03-21 | 2022-03-21 | 5 | 0d |  |  |  |
| 7 | 1.1.5 | Beoordeling en voorlopige gunning |  | 15d | 2022-03-22 | 2022-04-11 | 6 | 0d |  |  |  |
| 8 | 1.1.6 | Alcatel periode (kalenderdagen) |  | 21ed | 2022-04-11 | 2022-05-02 | 7 | 1.88d | 0d |  | werkdagen |
| 9 | 1.1.7 | Definitieve gunning | milestone | 0d | 2022-05-02 | 2022-05-02 | 8 | 0d |  |  |  |
| 10 | 2 | **UITVOERINGSFASE ZK ALPHEN NOORD** |  | 537d | 2022-05-09 | 2024-08-07 | 9 | 0d |  |  |  |
| 11 | 2.1 | Datum van aanvang | milestone | 0d | 2022-05-09 | 2022-05-09 | 9FS+5d | 0d |  |  |  |
| 12 | 2.2 | Engineering aannemer |  | 95d | 2022-05-10 | 2022-10-10 | 11 | 0d |  |  |  |
| 13 | 2.3 | Engineering aannemer gereed [UM] | milestone | 0d | 2022-10-10 | 2022-10-10 | 12 | 442d |  |  |  |
| 14 | 2.4 | Bestellen/reserveren long lead items (Ontwateringsmachine, silo, blowers) |  | 8mo | 2022-10-11 | 2023-06-05 | 12 | 0d |  |  |  |
| 15 | 2.5 | Bestellen en inkoop |  | 80d | 2022-10-11 | 2023-02-13 | 12 | 105d |  |  |  |
| 16 | 2.6 | **Werkzaamheden awzi Alphen Noord** |  | 435d | 2022-06-30 | 2024-05-08 |  | 65d |  |  |  |
| 17 | 2.6.1 | **Fase 0** |  | 0d | 2022-06-30 | 2022-06-30 |  | 500d |  |  |  |
| 18 | 2.6.1.1 | Aansluiting aangepast (Liander) | milestone | 0d | 2022-06-30 | 2022-06-30 |  | 500d |  | start no earlier than 2022-06-30 |  |
| 19 | 2.6.2 | **Fase 1** |  | 25d | 2022-10-11 | 2022-11-14 |  | 20d |  |  |  |
| 20 | 2.6.2.1 | Mobilisatie |  | 2w | 2022-10-11 | 2022-10-24 | 12 | 20d | 0d |  |  |
| 21 | 2.6.2.2 | Verplaatsen Lavafilter + slopen + paalfundering aanbrengen (boren) |  | 4w | 2022-10-11 | 2022-11-07 | 20SS | 20d | 0d |  |  |
| 22 | 2.6.2.3 | Installeren bemaling |  | 10d | 2022-11-01 | 2022-11-14 | 21FS-5d | 20d | 0d |  |  |
| 23 | 2.6.3 | **Fase 2** |  | 200d | 2022-11-15 | 2023-09-25 |  | 20d |  |  |  |
| 24 | 2.6.3.1 | Ontgraven bouwkuip (talud 1:2) voor OW+SE+SS+ER |  | 5d | 2022-11-15 | 2022-11-21 | 21, 22 | 20d | 0d |  |  |

| ID | WBS | Task | Type | Duration | Start | Finish | Predecessors | Total slack | Free slack |
| --- | --- | --- | --- | --- | --- | --- | --- | --- | --- |
| 25 | 2.6.3.2 | **ONTVANGWERK + SLIBONTWATERING +SILO+ E-RUIMTES + LEIDINGEN** |  | 195d | 2022-11-22 | 2023-09-25 |  | 20d |  |
| 26 | 2.6.3.2.1 | vloer + kespen leidingen |  | 5w | 2022-11-22 | 2023-01-09 | 24 | 20d | 0d |
| 27 | 2.6.3.2.2 | wanden |  | 6w | 2023-01-10 | 2023-02-20 | 26 | 20d | 0d |
| 28 | 2.6.3.2.3 | dek + uitharden |  | 4w | 2023-02-21 | 2023-03-20 | 27 | 20d | 0d |
| 29 | 2.6.3.2.4 | Aanbrengen staalconstructies en leuningen |  | 2w | 2023-03-07 | 2023-03-20 | 28FF | 337d |  |
| 30 | 2.6.3.2.5 | bouwkundige afwerking gebouw (rekening houden met stempels) |  | 7w | 2023-03-21 | 2023-05-08 | 28 | 20d | 0d |
| 31 | 2.6.3.2.6 | watertesten putten + leidingen |  | 10d | 2023-03-21 | 2023-04-03 | 27, 28 | 25d | 0d |
| 32 | 2.6.3.2.7 | Spanningsbemaling uit | milestone | 0d | 2023-04-03 | 2023-04-03 | 31 | 327d |  |
| 33 | 2.6.3.2.8 | aanvullen |  | 1w | 2023-04-04 | 2023-04-10 | 31 | 25d | 0d |
| 34 | 2.6.3.2.9 | container- en lavafilteropstelplaats |  | 3w | 2023-04-11 | 2023-05-01 | 33 | 25d | 5d |
| 35 | 2.6.3.2.10 | Silo + trap +bordessen plaatsen |  | 2w | 2023-04-11 | 2023-04-24 | 33 | 30d | 10d |
| 36 | 2.6.3.2.11 | geschikt voor W installatie | milestone | 0w | 2023-05-08 | 2023-05-08 | 30, 33, 34, 35 | 20d |  |
| 37 | 2.6.3.2.12 | Aanbrengen W en E installatie |  | 13w | 2023-06-06 | 2023-09-25 | 36, 14 | 0d |  |
| 38 | 2.6.3.2.13 | Aansluiten gebruikers bestaande installatie + gebruikers nieuwbouw op nieuwe MCC/MRK, zuivering blijft operationeel |  | 13w | 2023-06-06 | 2023-09-25 | 37FF | 0d |  |
| 39 | 2.6.3.2.14 | Aanpassen Terreinriolering en bedrijfswater in BG2 |  | 2w | 2023-09-12 | 2023-09-25 | 38FF | 127d | 107d |
| 40 | 2.6.4 | **Fase 3** |  | 40d | 2023-07-11 | 2023-09-25 |  | 0d |  |
| 41 | 2.6.4.1 | Aanpassen beluchtingstank 1 |  | 8w | 2023-07-11 | 2023-09-25 | 15, 38FF | 0d |  |
| 42 | 2.6.4.2 | Plaatsen tijdelijke beluchtingsinstallatie [TBI] |  | 1w | 2023-08-22 | 2023-08-28 | 37FS-25d, 41SS-5d | 217d | 0d |
| 43 | 2.6.4.3 | Vervangen blowerinstallatie en definitief aansluiten BT's |  | 4w | 2023-08-29 | 2023-09-25 | 42 | 217d |  |
| 44 | 2.6.5 | **Fase 4** |  | 40d | 2023-09-28 | 2023-11-22 |  | 0d |  |
| 45 | 2.6.5.1 | Aanpassen beluchtingstank 2 |  | 8w | 2023-09-28 | 2023-11-22 | 41FS+2d | 0d |  |
| 46 | 2.6.6 | **Fase 5** |  | 55d | 2023-11-09 | 2024-02-07 |  | 0d |  |
| 47 | 2.6.6.1 | Plaatsen en aansluiten TPI naar BT1 en BT2 vanaf nieuw roostergoedgebouw; [TPI] |  | 2w | 2023-11-09 | 2023-11-22 | 48SS, 45FS-10d | 0d |  |
| 48 | 2.6.6.2 | Plaatsen en aansluiten tijdelijk leidingwerk voor leeg pompen VBT |  | 2w | 2023-11-09 | 2023-11-22 | 45FS-10d | 0d |  |
| 49 | 2.6.6.3 | Buitengebruik stellen spoelen en leeg pompen voorbezinktank |  | 1w | 2023-11-23 | 2023-11-29 | 47 | 0d |  |
| 50 | 2.6.6.4 | Plaatsen en aansluiten TPI voor slibretourgemalen [TPI], afdichten verzamelput voor slibretourgemalen |  | 1w | 2023-11-23 | 2023-11-29 | 49FF | 40d | 0d |
| 51 | 2.6.6.5 | Aanpassen selector (incl. reinigen) |  | 4w | 2023-11-30 | 2024-01-10 | 47, 49 | 38d | 0d |
| 52 | 2.6.6.6 | Vervangen slibretourgemalen |  | 4w | 2023-11-30 | 2024-01-10 | 50 | 40d | 20d |
| 53 | 2.6.6.7 | Wachttijd ivm herstellen SVI |  | 4w | 2024-01-11 | 2024-02-07 | 51 | 20d | 0d |

| ID | WBS | Task | Type | Duration | Start | Finish | Predecessors | Total slack | Free slack |
| --- | --- | --- | --- | --- | --- | --- | --- | --- | --- |
| 54 | 2.6.7 | **Fase 6** |  | 10d | 2024-02-08 | 2024-02-21 |  | 20d |  |
| 55 | 2.6.7.1 | Aanpassen Nabezinktank 2 |  | 2w | 2024-02-08 | 2024-02-21 | 51FS+2d, 52, 53 | 20d | 0d |
| 56 | 2.6.8 | **Fase 7** |  | 120d | 2023-10-05 | 2024-04-03 |  | 90d |  |
| 57 | 2.6.8.1 | Aanpassen Nabezinktank 1 |  | 2w | 2024-02-22 | 2024-03-06 | 55 | 20d | 0d |
| 58 | 2.6.8.2 | Afronden en Capaciteitstest [TPI] |  | 4w | 2024-03-07 | 2024-04-03 | 57, 39 | 20d | 0d |
| 59 | 2.6.8.3 | AWZI volledig functioneel | milestone | 0d | 2024-04-03 | 2024-04-03 | 58 | 20d | 0d |
| 60 | 2.6.8.4 | Opleverdossier |  | 120d | 2023-10-05 | 2024-04-03 | 59FF | 90d |  |
| 61 | 2.6.9 | **Fase 8** |  | 105d | 2023-11-30 | 2024-05-08 |  | 0d |  |
| 62 | 2.6.9.1 | Slopen VBT + RGB + BG1 +SC (incl. bemaling) |  | 16w | 2023-11-30 | 2024-04-03 | 49 | 0d |  |
| 63 | 2.6.9.2 | Afwerken terrein, inclusief biodiversiteitsmaatregelen; |  | 4w | 2024-04-04 | 2024-05-01 | 62 | 0d |  |
| 64 | 2.6.9.3 | Demobilisatie. |  | 1w | 2024-05-02 | 2024-05-08 | 63, 59 | 0d |  |
| 65 | 2.7 | **Werkzaamheden AWTG Alphen Kennedylaan [TPI]** |  | 150d | 2022-05-10 | 2023-01-09 |  | 326d |  |
| 66 | 2.7.1 | Engineering C/W/E onderdelen lange levertijd |  | 40d | 2022-05-10 | 2022-07-04 | 11 | 326d | 0d |
| 67 | 2.7.2 | Bestellen C/W/E onderdelen lange levertijd |  | 80d | 2022-06-21 | 2022-10-31 | 66FS-10d | 427d | 0d |
| 68 | 2.7.3 | Werkplan TPI |  | 5d | 2022-05-24 | 2022-05-30 | 66SS+10d | 326d | 0d |
| 69 | 2.7.4 | Engineering gereed |  | 1d | 2022-07-05 | 2022-07-05 | 66 | 496d |  |
| 70 | 2.7.5 | Levertijd TPI |  | 70d | 2022-05-31 | 2022-09-26 | 68 | 326d | 0d |
| 71 | 2.7.6 | Levertijd schakelkast + FAT |  | 30d | 2022-06-21 | 2022-08-22 | 67SS | 477d |  |
| 72 | 2.7.7 | Plaatsen TPI |  | 5d | 2022-09-27 | 2022-10-03 | 70 | 326d | 0d |
| 73 | 2.7.8 | Proefdraaien TPI |  | 5d | 2022-10-04 | 2022-10-10 | 72 | 326d | 0d |
| 74 | 2.7.9 | Bedrijfsperiode TPI |  | 55d | 2022-10-11 | 2023-01-09 | 73 | 326d | 0d |
| 75 | 2.7.10 | Amoveren bestaande installaties C/W/E |  | 10d | 2022-10-11 | 2022-10-24 | 74SS | 326d | 0d |
| 76 | 2.7.11 | Civiele werkzaamheden |  | 15d | 2022-10-25 | 2022-11-14 | 75 | 336d | 10d |
| 77 | 2.7.12 | Werktuigbouwkundige werkzaamheden |  | 15d | 2022-10-25 | 2022-11-14 | 75 | 336d | 10d |
| 78 | 2.7.13 | Elektrotechnische werkzaamheden |  | 25d | 2022-10-25 | 2022-11-28 | 75 | 326d | 0d |
| 79 | 2.7.14 | Montage eind inspectie (WTB/ E) |  | 1d | 2022-11-29 | 2022-11-29 | 76, 77, 78 | 326d | 0d |
| 80 | 2.7.15 | I/O testen |  | 5d | 2022-11-30 | 2022-12-06 | 79 | 326d | 0d |
| 81 | 2.7.16 | PA Sotware implementeren |  | 1d | 2022-12-07 | 2022-12-07 | 80 | 326d | 0d |
| 82 | 2.7.17 | SAT capaciteitstest 1 |  | 2d | 2022-12-08 | 2022-12-09 | 81 | 326d | 0d |
| 83 | 2.7.18 | Inbedrijfname AWTG |  | 1d | 2022-12-12 | 2022-12-12 | 82 | 326d | 0d |
| 84 | 2.7.19 | 7 dagen test (storingsvrije periode) |  | 7ed | 2022-12-12 | 2022-12-19 | 83 | 1516.88d | 1.88d |
| 85 | 2.7.20 | Restpunten/ Terreinafwerking |  | 5d | 2022-12-13 | 2022-12-19 | 83 | 326d | 0d |
| 86 | 2.7.21 | Opleverdossier |  | 80d | 2022-08-23 | 2022-12-13 | 66SS, 85SF | 331d | 5d |
| 87 | 2.7.22 | Vervroegde ingebruikneming AWTG |  | 1d | 2022-12-20 | 2022-12-20 | 84, 85, 86 | 326d |  |
| 88 | 2.8 | Oplevering (MIJLPAAL) | milestone | 0d | 2024-05-08 | 2024-05-08 | 62, 64, 87 | 0d |  |
| 89 | 2.9 | Restpunten en nazorg |  | 13w | 2024-05-09 | 2024-08-07 | 88 | 0d |  |
