# 20190612 Planning rwzi Nieuwveen DO-Oplevering

Schedule from MS Project, 2021-10-27 to 2024-02-12.
Royal Haskoning

## Calendars

- Standard: Mon-Fri 08:00-12:00, 13:00-17:00; Sat-Sun off. Exceptions (off unless hours are given): 2021-12-27 to 2022-01-07 (kerstvakantie 2021), 2022-08-01 to 2022-08-19 (zomervakantie 2022), 2022-12-24 to 2023-01-08 (kerstvakantie 2022), 2023-07-31 to 2023-08-18 (Zomervakantie 2023), 2023-12-25 to 2024-01-05 (Kerstvakantie 2023).
- werkdagen: Mon-Fri 08:00-12:00, 13:00-17:00; Sat-Sun 09:00-12:00, 13:00-17:00.

## Schedule

| ID | WBS | Task | Type | Duration | Start | Finish | Predecessors | Total slack | Free slack | Calendar |
| --- | --- | --- | --- | --- | --- | --- | --- | --- | --- | --- |
| 1 | 1 | **Activiteiten HHR** |  | 124d | 2021-10-27 | 2022-05-02 |  | 30d |  |  |
| 2 | 1.1 | **Aanbesteding en gunningsfase AKZ** |  | 124d | 2021-10-27 | 2022-05-02 |  | 30d |  |  |
| 3 | 1.1.1 | Voorbereiding aanbesteding |  | 30d | 2021-10-27 | 2021-12-08 | 4SF | 509d |  |  |
| 4 | 1.1.2 | Contractstukken opsturen naar aannemers | manual | 1d | 2021-12-08 | 2021-12-08 |  |  |  |  |
| 5 | 1.1.3 | Rekentijd aannemers + NVI (kalenderdagen) |  | 102ed | 2021-12-08 | 2022-03-20 | 4 | 1.88d |  | werkdagen |
| 6 | 1.1.4 | Indienen aanbestedingsdocumenten aannemers |  | 1d | 2022-03-21 | 2022-03-21 | 5 | 0d |  |  |
| 7 | 1.1.5 | Beoordeling en voorlopige gunning |  | 15d | 2022-03-22 | 2022-04-11 | 6 | 0d |  |  |
| 8 | 1.1.6 | Alcatel periode (kalenderdagen) |  | 21ed | 2022-04-11 | 2022-05-02 | 7 | 1.88d | 0d | werkdagen |
| 9 | 1.1.7 | Definitieve gunning | milestone | 0d | 2022-05-02 | 2022-05-02 | 8 | 0d |  |  |
| 10 | 2 | **UITVOERINGSFASE ZK ALPHEN KERK EN ZANEN** |  | 410d | 2022-05-09 | 2024-02-12 |  | 0d |  |  |
| 11 | 2.1 | Datum aanvang | milestone | 0d | 2022-05-09 | 2022-05-09 | 9FS+5d | 0d |  |  |
| 12 | 2.2 | Engineering aannemer |  | 95d | 2022-05-10 | 2022-10-10 | 9, 11 | 0d |  |  |
| 13 | 2.3 | Engineerin aannemer gereed [UM] | milestone | 0d | 2022-10-10 | 2022-10-10 | 12 | 315d |  |  |
| 14 | 2.4 | Bestellen/reserveren long lead items (Ontwateringsmachine, silo, roosters, blowers, verdelers) |  | 8mo | 2022-10-11 | 2023-06-05 | 12 | 0d |  |  |
| 15 | 2.5 | Bestellen en inkoop mengers en equipement selector en contactruimte |  | 40d | 2022-10-11 | 2022-12-05 | 12 | 81d | 30d |  |
| 16 | 2.6 | Bestellen en produceren skids plaatbeluchting |  | 60d | 2022-10-11 | 2023-01-16 | 12 | 96d | 45d |  |
| 17 | 2.7 | Bestellen en inkoop overige items |  | 80d | 2022-10-11 | 2023-02-13 | 12 | 3d | 0d |  |
| 18 | 2.8 | **Werkzaamheden awzi Alphen Kerk en Zanen** |  | 160d | 2023-01-17 | 2023-09-18 |  | 3d |  |  |
| 19 | 2.8.1 | Mobilisatie |  | 2w | 2023-01-17 | 2023-01-30 | 12, 17FS-20d | 3d | 0d |  |
| 20 | 2.8.2 | **Fase 1 - Contactruimte en anaerobe ruimte** |  | 20d | 2023-01-31 | 2023-02-27 |  | 51d |  |  |
| 21 | 2.8.2.1 | Reinigen contactruimte en anaerobe ruimte |  | 5d | 2023-01-31 | 2023-02-06 | 19, 15 | 51d | 0d |  |
| 22 | 2.8.2.2 | Repareren beton en lining |  | 2w | 2023-02-07 | 2023-02-20 | 21 | 51d | 0d |  |
| 23 | 2.8.2.3 | Monteren en aansluiten mengers (op bestaande voeding) |  | 2w | 2023-02-07 | 2023-02-20 | 21, 15 | 51d | 0d |  |
| 24 | 2.8.2.4 | SAT en IBS |  | 5d | 2023-02-21 | 2023-02-27 | 22, 23 | 51d | 0d |  |

| ID | WBS | Task | Type | Duration | Start | Finish | Predecessors | Total slack | Free slack | Constraint |
| --- | --- | --- | --- | --- | --- | --- | --- | --- | --- | --- |
| 25 | 2.8.3 | **Fase 2 - Aanpassen Beluchtingstank 1** |  | 25d | 2023-02-28 | 2023-04-03 |  | 51d |  |  |
| 26 | 2.8.3.1 | Inblokken, leegpompen en reinigen |  | 1w | 2023-02-28 | 2023-03-06 | 24 | 51d | 0d |  |
| 27 | 2.8.3.2 | Aanpassen luchtleidingen (alleen t.b.v. aansluiten skids platen) |  | 2w | 2023-03-07 | 2023-03-20 | 26 | 51d | 0d |  |
| 28 | 2.8.3.3 | Verwijderen schotels en betonreparaties |  | 2w | 2023-03-07 | 2023-03-20 | 26 | 51d | 0d |  |
| 29 | 2.8.3.4 | Inhijsen skids plaatbeluchting en aansluiten |  | 1w | 2023-03-21 | 2023-03-27 | 28, 27, 16 | 51d | 0d |  |
| 30 | 2.8.3.5 | Vullen en in bedrijf stellen |  | 1w | 2023-03-28 | 2023-04-03 | 29 | 51d | 0d |  |
| 31 | 2.8.4 | **Fase 3 - Aanpassen Beluchtingstank 2** |  | 25d | 2023-04-04 | 2023-05-08 |  | 51d |  |  |
| 32 | 2.8.4.1 | Inblokken, leegpompen en reinigen |  | 1w | 2023-04-04 | 2023-04-10 | 24, 30 | 51d | 0d |  |
| 33 | 2.8.4.2 | Aanpassen luchtleidingen (alleen t.b.v. aansluiten skids platen) |  | 2w | 2023-04-11 | 2023-04-24 | 32 | 51d | 0d |  |
| 34 | 2.8.4.3 | Verwijderen schotels en betonreparaties |  | 2w | 2023-04-11 | 2023-04-24 | 32 | 51d | 0d |  |
| 35 | 2.8.4.4 | Inhijsen skids plaatbeluchting en aansluiten |  | 1w | 2023-04-25 | 2023-05-01 | 33, 34, 16 | 51d | 0d |  |
| 36 | 2.8.4.5 | Vullen en in bedrijf stellen |  | 1w | 2023-05-02 | 2023-05-08 | 35 | 51d | 0d |  |
| 37 | 2.8.5 | **Fase 4** |  | 15d | 2023-05-09 | 2023-05-29 |  | 51d |  |  |
| 38 | 2.8.5.1 | Plaatsen TPI slibretour (1200 m3/uur) |  | 5d | 2023-05-09 | 2023-05-15 | 36 | 51d | 0d |  |
| 39 | 2.8.5.2 | Aanpassen Nabezinktank 2 |  | 2w | 2023-05-16 | 2023-05-29 | 36FS+5d, 38 | 51d | 0d |  |
| 40 | 2.8.6 | **Fase 5** |  | 16d | 2023-05-30 | 2023-06-20 |  | 51d |  |  |
| 41 | 2.8.6.1 | Plaatsen TPI gedeeltelijke bypass 700 mm leiding |  | 4d | 2023-05-30 | 2023-06-02 | 39 | 51d | 0d |  |
| 42 | 2.8.6.2 | Aanpassen Nabezinktank 1 |  | 2w | 2023-06-05 | 2023-06-16 | 39, 41 | 51d | 0d |  |
| 43 | 2.8.6.3 | Ombouw tanks gereed [UM] | milestone | 0d | 2023-06-16 | 2023-06-16 | 42 | 146d |  |  |
| 44 | 2.8.6.4 | Verwijderen TPI's slibretour en bypass verwijderen |  | 2d | 2023-06-19 | 2023-06-20 | 42 | 144d |  |  |
| 45 | 2.8.7 | **Overige aanpassingen:** |  | 160d | 2023-01-17 | 2023-09-18 |  | 3d |  |  |
| 46 | 2.8.7.1 | Rooien begroeiing (Romneyloods, zonneweide en biodiversiteit) na bouwvak ivm broedseizoen |  | 2w | 2023-01-17 | 2023-01-30 | 19FS-10d | 3d | 0d | start no earlier than 2022-08-29 |
| 47 | 2.8.7.2 | Verplaatsen Romneyloods |  | 2w | 2023-01-24 | 2023-02-06 | 46FS-5d | 3d | 0d |  |
| 48 | 2.8.7.3 | Opstellen en aansluiten tijdelijke slibverlading en tijdelijk geurfilter waterlijn |  | 2w | 2023-01-17 | 2023-01-30 | 46SS | 8d | 5d |  |
| 49 | 2.8.7.4 | Slopen slibverlading en geurfilters en overig voorbereiden grondwerk voor Terreinrioolput, E&I gebouw en 2e influentgoot |  | 2w | 2023-02-07 | 2023-02-20 | 48, 47 | 3d | 0d |  |
| 50 | 2.8.7.5 | Schroefpalen voor diverse objecten aanbrengen |  | 2w | 2023-02-21 | 2023-03-06 | 49 | 3d | 0d |  |

| ID | WBS | Task | Duration | Start | Finish | Predecessors | Total slack | Free slack |
| --- | --- | --- | --- | --- | --- | --- | --- | --- |
| 51 | 2.8.7.6 | **Funderingen** | 34d | 2023-02-28 | 2023-04-16 |  | 3d |  |
| 52 | 2.8.7.6.1 | Fundering E&I gebouw | 5d | 2023-02-28 | 2023-03-06 | 50FS-5d | 3d | 0d |
| 53 | 2.8.7.6.2 | Uitharden fundering E&I gebouw | 20ed | 2023-03-06 | 2023-03-26 | 52 | 130.88d | 1.88d |
| 54 | 2.8.7.6.3 | Overige funderingen | 15d | 2023-03-07 | 2023-03-27 | 52 | 3d | 0d |
| 55 | 2.8.7.6.4 | Uitharden funderingen | 20ed | 2023-03-27 | 2023-04-16 | 54 | 10.88d | 1.88d |
| 56 | 2.8.7.7 | **Geurfilters waterlijn** | 25d | 2023-04-17 | 2023-05-19 |  | 71d |  |
| 57 | 2.8.7.7.1 | Plaatsen en aansluiten nieuwe geurfilters waterlijn | 25d | 2023-04-17 | 2023-05-19 | 55, 17 | 71d |  |
| 58 | 2.8.7.8 | **E&I gebouw** | 95d | 2023-02-07 | 2023-06-19 |  | 65d |  |
| 59 | 2.8.7.8.1 | Trekputten en mantelbuizen aanbrengen | 4w | 2023-02-07 | 2023-03-06 | 47 | 220d |  |
| 60 | 2.8.7.8.2 | E&I gebouw bouwen | 20d | 2023-03-27 | 2023-04-21 | 53 | 31d |  |
| 61 | 2.8.7.8.3 | Verdelers en kasten plaatsen en aansluiten op trafo | 2w | 2023-06-06 | 2023-06-19 | 60, 17, 14 | 0d |  |
| 62 | 2.8.7.9 | **Slibontwatering** | 55d | 2023-06-13 | 2023-09-18 |  | 5d |  |
| 63 | 2.8.7.9.1 | Plaatsen tijdelijke slibonwateringsvoorziening | 5d | 2023-06-13 | 2023-06-20 | 64SF | 145d |  |
| 64 | 2.8.7.9.2 | Verwijderen slibontwateringsmachine | 5d | 2023-06-20 | 2023-06-26 | 52FF, 61 | 0d |  |
| 65 | 2.8.7.9.3 | Plaatsen Nieuwe slibontwateringsmachine | 5d | 2023-06-20 | 2023-06-26 | 64FS-5d, 14 | 0d |  |
| 66 | 2.8.7.9.4 | Plaatsen slibsilo | 5d | 2023-06-20 | 2023-06-26 | 65SS, 14, 55 | 140d |  |
| 67 | 2.8.7.9.5 | Afmonteren ontwateringsinstallaties en slibsilo W+E | 6w | 2023-06-27 | 2023-08-28 | 65 | 0d |  |
| 68 | 2.8.7.9.6 | SAT Slibontwatering en storingsvrije periode | 2w | 2023-08-29 | 2023-09-11 | 67 | 0d |  |
| 69 | 2.8.7.9.7 | Verwijderen tijdelijke slibontwatering en verlading | 1w | 2023-09-12 | 2023-09-18 | 68 | 0d |  |
| 70 | 2.8.7.10 | **Blowers** | 46d | 2023-06-13 | 2023-09-05 |  | 9d |  |
| 71 | 2.8.7.10.1 | Plaatsen aansluiten en testen nieuwe blower 4 | 3w | 2023-06-13 | 2023-07-03 | 61FS-5d, 14 | 9d | 0d |
| 72 | 2.8.7.10.2 | Vervangen blower 1 | 2w | 2023-07-05 | 2023-07-18 | 14, 71FS+1d | 9d | 0d |
| 73 | 2.8.7.10.3 | Vervangen blower 2 | 2w | 2023-07-19 | 2023-08-22 | 72 | 9d | 0d |
| 74 | 2.8.7.10.4 | Vervangen blower 3 | 2w | 2023-08-23 | 2023-09-05 | 73 | 9d |  |

| ID | WBS | Task | Duration | Start | Finish | Predecessors | Total slack | Free slack |
| --- | --- | --- | --- | --- | --- | --- | --- | --- |
| 75 | 2.8.7.11 | **Roostergoed** | 94d | 2023-04-17 | 2023-09-14 |  | 2d |  |
| 76 | 2.8.7.11.1 | Bouwen 2e influentgoot en roostergoedgoot | 9w | 2023-04-17 | 2023-06-16 | 50, 55 | 3d | 1d |
| 77 | 2.8.7.11.2 | Opstellen en aansluiten tijdelijke roostergoedinstallatie | 2w | 2023-06-20 | 2023-07-03 | 61, 76 | 2d | 0d |
| 78 | 2.8.7.11.3 | Schuiven, Roostergoedinstallaties aanbrengen, zandvang reinigen en repareren | 30d | 2023-07-04 | 2023-09-04 | 77, 61, 14 | 2d | 0d |
| 79 | 2.8.7.11.4 | Testen en IBS | 5d | 2023-09-05 | 2023-09-11 | 78 | 2d | 0d |
| 80 | 2.8.7.11.5 | Verwijderen tijdelijk roostergoedinstallatie | 3d | 2023-09-12 | 2023-09-14 | 79 | 2d |  |
| 81 | 2.8.7.12 | **Terreinriolering en bedrijfswater** | 15d | 2023-06-20 | 2023-07-10 |  | 35d |  |
| 82 | 2.8.7.12.1 | Plaatsen prefab terreinrioolput | 5d | 2023-06-20 | 2023-06-26 | 50FS+10d, 17, 61 | 35d | 0d |
| 83 | 2.8.7.12.2 | Inrichten en aansluiten terreinriolering en afvoer | 10d | 2023-06-27 | 2023-07-10 | 82 | 35d |  |
| 84 | 2.8.7.13 | **Retourslibgemaal** | 35d | 2023-06-13 | 2023-08-21 |  | 25d |  |
| 85 | 2.8.7.13.1 | Plaatsen TPI voor retourslib | 5d | 2023-06-13 | 2023-06-19 | 86SS-5d | 145d |  |
| 86 | 2.8.7.13.2 | Slopen installaties | 1w | 2023-06-20 | 2023-06-26 | 61 | 20d | 0d |
| 87 | 2.8.7.13.3 | Betonreparaties | 1w | 2023-06-27 | 2023-07-03 | 86 | 20d | 0d |
| 88 | 2.8.7.13.4 | Monteren nieuwe gemalen | 2w | 2023-07-04 | 2023-07-17 | 87, 17 | 20d | 0d |
| 89 | 2.8.7.13.5 | Indraaien en SAT | 5d | 2023-07-18 | 2023-07-24 | 88 | 20d | 0d |
| 90 | 2.8.7.13.6 | Verwijderen tijdelijke retourslibinstallatie | 5d | 2023-07-25 | 2023-08-21 | 89 | 20d |  |
| 91 | 2.8.7.14 | **Afwerken tanks** | 40d | 2023-06-20 | 2023-09-04 |  | 10d |  |
| 92 | 2.8.7.14.1 | Afmonteren en definitief aansluiten apparatuur selector | 2w | 2023-06-20 | 2023-07-03 | 61 | 10d | 0d |
| 93 | 2.8.7.14.2 | Afmonteren en definitief aansluiten apparatuur AT1 | 2w | 2023-07-04 | 2023-07-17 | 92 | 10d | 0d |
| 94 | 2.8.7.14.3 | Afmonteren en definitief aansluiten apparatuur AT2 | 2w | 2023-07-18 | 2023-08-21 | 93 | 10d | 0d |
| 95 | 2.8.7.14.4 | Afmonteren en definitief aansluiten NBT1 | 1w | 2023-08-22 | 2023-08-28 | 94 | 10d | 0d |
| 96 | 2.8.7.14.5 | Afmonteren en definitief aansluiten NBT 2 | 1w | 2023-08-29 | 2023-09-04 | 95 | 10d |  |
| 97 | 2.9 | Afronden en ISAT | 6w | 2023-09-19 | 2023-10-30 | 42, 90, 83, 80, 74, 69, 57, 96 | 0d |  |
| 98 | 2.10 | **AWTG's** | 216d | 2022-05-10 | 2023-04-11 |  | 129d |  |
| 99 | 2.10.1 | **Werkzaamheden AWTG Alphen West** | 150d | 2022-05-10 | 2023-01-09 |  | 129d |  |
| 100 | 2.10.1.1 | Engineering C/W/E onderdelen lange levertijd | 40d | 2022-05-10 | 2022-07-04 | 11 | 129d | 0d |
| 101 | 2.10.1.2 | Bestellen C/W/E onderdelen lange levertijd | 80d | 2022-06-21 | 2022-10-31 | 100FS-10d | 300d | 0d |
| 102 | 2.10.1.3 | Werkplan TPI | 5d | 2022-05-24 | 2022-05-30 | 100SS+10d | 129d | 0d |
| 103 | 2.10.1.4 | Engineering gereed | 1d | 2022-07-05 | 2022-07-05 | 100 | 369d |  |
| 104 | 2.10.1.5 | Levertijd pompen + FAT | 80d | 2022-06-21 | 2022-10-31 | 101SS | 300d |  |
| 105 | 2.10.1.6 | Levertijd TPI | 70d | 2022-05-31 | 2022-09-26 | 102 | 129d | 0d |
| 106 | 2.10.1.7 | Levertijd schakelkast + FAT | 30d | 2022-06-21 | 2022-08-22 | 101SS | 350d |  |
| 107 | 2.10.1.8 | Plaatsen TPI | 5d | 2022-09-27 | 2022-10-03 | 105 | 129d | 0d |
| 108 | 2.10.1.9 | Proefdraaien TPI | 5d | 2022-10-04 | 2022-10-10 | 107 | 129d | 0d |
| 109 | 2.10.1.10 | Bedrijfsperiode TPI | 55d | 2022-10-11 | 2023-01-09 | 108 | 129d | 0d |
| 110 | 2.10.1.11 | Amoveren bestaande installaties C/W/E | 10d | 2022-10-11 | 2022-10-24 | 109SS | 194d | 0d |
| 111 | 2.10.1.12 | Civiele werkzaamheden | 10d | 2022-10-25 | 2022-11-07 | 110 | 209d | 15d |
| 112 | 2.10.1.13 | Werktuigbouwkundige werkzaamheden | 15d | 2022-10-25 | 2022-11-14 | 110 | 204d | 10d |
| 113 | 2.10.1.14 | Elektrotechnische werkzaamheden | 25d | 2022-10-25 | 2022-11-28 | 110 | 194d | 0d |
| 114 | 2.10.1.15 | Montage eind inspectie (WTB/ E) | 1d | 2022-11-29 | 2022-11-29 | 111, 112, 113 | 194d | 0d |
| 115 | 2.10.1.16 | I/O testen | 5d | 2022-11-30 | 2022-12-06 | 114 | 194d | 0d |
| 116 | 2.10.1.17 | PA Sotware implementeren | 1d | 2022-12-07 | 2022-12-07 | 115 | 194d | 0d |
| 117 | 2.10.1.18 | SAT capaciteitstest 1 | 2d | 2022-12-08 | 2022-12-09 | 116 | 194d | 0d |
| 118 | 2.10.1.19 | Inbedrijfname AWTG | 1d | 2022-12-12 | 2022-12-12 | 117 | 194d | 0d |
| 119 | 2.10.1.20 | 14 dagen test (storingsvrije periode) | 14ed | 2022-12-12 | 2022-12-26 | 118 | 922.88d | 40.88d |
| 120 | 2.10.1.21 | Restpunten/ Terreinafwerking | 5d | 2022-12-13 | 2022-12-19 | 118 | 199d | 0d |
| 121 | 2.10.1.22 | Opleverdossier | 80d | 2022-08-23 | 2022-12-13 | 100SS, 120SF | 204d | 9d |
| 122 | 2.10.1.23 | Vervroegde ingebruikneming AWTG | 1d | 2023-01-09 | 2023-01-09 | 119, 120, 121 | 195d |  |

| ID | WBS | Task | Duration | Start | Finish | Predecessors | Total slack | Free slack |
| --- | --- | --- | --- | --- | --- | --- | --- | --- |
| 123 | 2.10.2 | **Werkzaamheden AWTG Alphen Kerk en Zanen** | 201d | 2022-05-31 | 2023-04-11 |  | 179d |  |
| 124 | 2.10.2.1 | Engineering C/W/E onderdelen lange levertijd | 40d | 2022-05-31 | 2022-07-25 | 100SS+15d | 179d | 0d |
| 125 | 2.10.2.2 | Bestellen C/W/E onderdelen lange levertijd | 80d | 2022-07-12 | 2022-11-21 | 124FS-10d | 189d | 0d |
| 126 | 2.10.2.3 | Werkplan TPI | 5d | 2022-06-14 | 2022-06-20 | 124SS+10d | 179d | 0d |
| 127 | 2.10.2.4 | Engineering gereed | 1d | 2022-07-26 | 2022-07-26 | 124 | 354d |  |
| 128 | 2.10.2.5 | Levertijd pompen + FAT | 80d | 2022-07-12 | 2022-11-21 | 125SS | 285d |  |
| 129 | 2.10.2.6 | Levertijd TPI | 70d | 2022-06-21 | 2022-10-17 | 126 | 179d | 50d |
| 130 | 2.10.2.7 | Levertijd schakelkast + FAT | 30d | 2022-07-12 | 2022-09-12 | 125SS | 335d |  |
| 131 | 2.10.2.8 | Plaatsen TPI | 5d | 2023-01-10 | 2023-01-16 | 129, 109 | 129d | 0d |
| 132 | 2.10.2.9 | Proefdraaien TPI | 5d | 2023-01-17 | 2023-01-23 | 131 | 129d | 0d |
| 133 | 2.10.2.10 | Bedrijfsperiode TPI | 55d | 2023-01-24 | 2023-04-10 | 132 | 129d | 0d |
| 134 | 2.10.2.11 | Amoveren bestaande installaties C/W/E | 10d | 2023-01-24 | 2023-02-06 | 133SS | 129d | 0d |
| 135 | 2.10.2.12 | Civiele werkzaamheden | 25d | 2023-02-07 | 2023-03-13 | 134 | 129d | 0d |
| 136 | 2.10.2.13 | Werktuigbouwkundige werkzaamheden | 10d | 2023-02-07 | 2023-02-20 | 134 | 144d | 15d |
| 137 | 2.10.2.14 | Elektrotechnische werkzaamheden | 25d | 2023-02-07 | 2023-03-13 | 134 | 129d | 0d |
| 138 | 2.10.2.15 | Montage eind inspectie (WTB/ E) | 1d | 2023-03-14 | 2023-03-14 | 135, 136, 137, 148 | 129d | 0d |
| 139 | 2.10.2.16 | I/O testen | 5d | 2023-03-15 | 2023-03-21 | 138 | 129d | 0d |
| 140 | 2.10.2.17 | PA Sotware implementeren | 1d | 2023-03-22 | 2023-03-22 | 139 | 129d | 0d |
| 141 | 2.10.2.18 | SAT capaciteitstest 1 | 2d | 2023-03-23 | 2023-03-24 | 140 | 129d | 0d |
| 142 | 2.10.2.19 | Inbedrijfname AWTG | 1d | 2023-03-27 | 2023-03-27 | 141 | 129d | 0d |
| 143 | 2.10.2.20 | 14 dagen test (storingsvrije periode) | 14ed | 2023-03-27 | 2023-04-10 | 142 | 607.88d | 1.88d |
| 144 | 2.10.2.21 | Restpunten/ Terreinafwerking | 5d | 2023-03-28 | 2023-04-03 | 142 | 134d | 0d |
| 145 | 2.10.2.22 | Opleverdossier | 80d | 2022-11-22 | 2023-03-28 | 124SS, 144SF | 139d | 10d |
| 146 | 2.10.2.23 | Vervroegde ingebruikneming AWTG | 1d | 2023-04-11 | 2023-04-11 | 143, 144, 145 | 129d |  |

| ID | WBS | Task | Type | Duration | Start | Finish | Predecessors | Total slack | Free slack |
| --- | --- | --- | --- | --- | --- | --- | --- | --- | --- |
| 147 | 2.10.3 | **Werkzaamheden AWTG Hazerwoude Rijndijk** |  | 16d | 2022-11-14 | 2022-12-06 |  | 194.5d |  |
| 148 | 2.10.3.1 | Civiele werkzaamheden |  | 10d | 2022-11-22 | 2022-12-05 | 125 | 189d | 60d |
| 149 | 2.10.3.2 | Monteren en aansluiten meting |  | 2d | 2022-11-22 | 2022-11-23 | 125 | 274.5d | 0d |
| 150 | 2.10.3.3 | Montage eind inspectie (WTB/ E) |  | 1d | 2022-11-24 | 2022-11-24 | 149 | 274.5d | 0d |
| 151 | 2.10.3.4 | I/O testen |  | 0.5d | 2022-11-25 | 2022-11-25 | 150 | 274.5d | 0d |
| 152 | 2.10.3.5 | PA Sotware implementeren |  | 0.5d | 2022-11-25 | 2022-11-25 | 151 | 274.5d | 0d |
| 153 | 2.10.3.6 | SAT capaciteitstest 1 |  | 0.5d | 2022-11-28 | 2022-11-28 | 152 | 274.5d | 0d |
| 154 | 2.10.3.7 | Inbedrijfname AWTG | milestone | 0d | 2022-11-28 | 2022-11-28 | 153 | 274.5d | 0d |
| 155 | 2.10.3.8 | Restpunten/ Terreinafwerking |  | 5d | 2022-11-28 | 2022-12-05 | 154 | 274.5d | 0d |
| 156 | 2.10.3.9 | Opleverdossier |  | 10d | 2022-11-14 | 2022-11-28 | 155SF | 279.5d | 5d |
| 157 | 2.10.3.10 | Vervroegde ingebruikneming AWTG |  | 1d | 2022-12-05 | 2022-12-06 | 155, 156 | 274.5d |  |
| 158 | 2.11 | Oplevering (MIJLPAAL) | milestone | 0d | 2023-10-30 | 2023-10-30 | 97, 146, 122 | 0d |  |
| 159 | 2.12 | Restpunten en nazorg |  | 13w | 2023-10-31 | 2024-02-12 | 158 | 0d |  |
